# Proyecto G1

Schedule from MS Project, 2011-01-03 to 2015-11-27, A marks actual dates.
AIS - DINACIA

## Calendars

- Estándar: Mon-Fri 08:00-14:00, 15:00-17:00; Sat-Sun off.

## Resources

| Resource |
| --- |
| Pablo Collazo |
| Coordinador OACI |
| P=ablo Collazo |
| Pablo Collazo y Coordinador OACI |
| Pablo Collazo/Coordinador OACI |
| No Determinado/Coordinador OACI |
| No Determinado/Coordinador OACI |
| No Determinado |

## Schedule

| ID | WBS | Task | Duration | Start | Finish | Predecessors | Complete | Remaining | Total slack | Free slack | Constraint | Resources | Work | Actual work |
| --- | --- | --- | --- | --- | --- | --- | --- | --- | --- | --- | --- | --- | --- | --- |
| 1 | 1 | **Implantación de Sistemas de Intercambio de Información Aeronáutica(AIXM)Aeronautical Información Systems Data Exchange (AIXM)** | 1280d? | 2011-01-03 A | 2015-11-27 |  | 10% | 1151.45d? | 0d |  |  | Coordinador OACI | 19773h | 1712h |
| 2 | 1.1 | **Identificar el estado de implantación sobre el suministro de Documentación Integrada IAIP/Identify status of implementation on the provision of integrated AIP documentation** | 51d | 2012-03-01 A | 2012-05-10 A |  | 100% |  |  |  |  |  | 1048h | 1048h |
| 3 | 1.1.1 | Relevamiento de suministro de la IAIP mediante el uso de una tabla/Collection of IAIP provision through the use of a table | 51d | 2012-03-01 A | 2012-05-10 A |  | 100% |  |  |  | finish no earlier than 2012-03-16 | Coordinador OACI | 408h | 408h |
| 4 | 1.1.2 | Distribución a los Estados/Distribution to States | 51d | 2012-03-01 A | 2012-05-10 A |  | 100% |  |  |  | finish no earlier than 2012-03-16 | Coordinador OACI | 408h | 408h |
| 5 | 1.1.3 | Recolección y Actualización/Collection and updating | 29d | 2012-03-01 A | 2012-04-10 A |  | 100% |  |  |  | start no earlier than 2012-02-07 | Coordinador OACI | 232h | 232h |
| 6 | 1.2 | **AIP Electrónico/Electronic AIP** | 675d? | 2012-03-01 A | 2014-10-01 |  | 43% | 387d? | 302d |  |  |  | 256h | 256h |
| 7 | 1.2.1 | Recolección de experiencias en los Estados de la Región SAM/Collection of experiences in the SAM Región States | 32d | 2012-03-01 A | 2012-04-13 A |  | 100% |  |  |  | start no earlier than 2012-02-02 | Coordinador OACI | 256h | 256h |
| 8 | 1.2.2 | Analizar especificaciones AIXM de Eurocontrol/ Analize Eurocontrol AIXM specifications. | 43d? | 2014-08-04 | 2014-10-01 |  |  |  | 284d |  | finish no earlier than 2014-10-01 |  |  |  |
| 9 | 1.3 | Modelo de Intercambio de Información Aeronáutica (AIXM)/Aeronautical Information Exchange Management (AIXM) | 1262d? | 2011-01-03 | 2015-11-03 |  |  |  | 1d |  |  | Coordinador OACI | 10096h |  |
| 10 | 1.4 | **Recopilación de las Especificaciones AIXM/Collection AIXM specifications** | 105d | 2015-04-13 | 2015-09-04 |  |  |  | 60d |  |  |  | 440h |  |
| 11 | 1.4.1 | Desarrollar Plan de Acción AIXM/Develop AIXM Action Plan | 10d | 2015-04-13 | 2015-04-24 |  |  |  | 140d | 5d | finish no earlier than 2015-04-24 |  |  |  |
| 12 | 1.4.2 | Recopilación de la documentación AIXM/Collect AIXM documentation | 15d | 2015-05-04 | 2015-05-22 | 11 |  |  | 135d |  | finish no earlier than 2015-05-22 | Coordinador OACI | 120h |  |
| 13 | 1.4.3 | Traducción de la documentación AIXM/Translate AIXM documentation | 25d | 2015-05-27 | 2015-06-30 |  |  |  | 78d | 0d | finish no earlier than 2015-06-30 | Coordinador OACI | 200h |  |
| 14 | 1.4.4 | Revisión de la documentación AIXM/Review AIXM documentation | 30d | 2015-07-01 | 2015-08-11 | 13 |  |  | 78d |  |  |  |  |  |
| 15 | 1.4.5 | Obtención de la documentación validada/Obtain validated documentation | 15d | 2015-08-17 | 2015-09-04 |  |  |  | 60d |  | start no earlier than 2015-08-17 | Coordinador OACI | 120h |  |
| 16 | 1.5 | **Pruebas de Transmisión/Recepción de datos AIXM/AIXM data transmission/reception tests** | 40d | 2015-09-14 | 2015-11-06 |  |  |  | 15d |  |  |  | 120h |  |
| 17 | 1.5.1 | Elaboración de documento describiendo los pasos para las pruebas/Elaboration of document describing steps for tests | 15d | 2015-09-14 | 2015-10-02 |  |  |  | 15d | 0d | start no earlier than 2015-09-14 | Coordinador OACI | 120h |  |
| 18 | 1.5.2 | Realización de las pruebas AIXM/AIXM tests | 15d | 2015-10-05 | 2015-10-23 | 17 |  |  | 15d | 0d |  |  |  |  |
| 19 | 1.5.3 | Informe de resultado de las pruebas de transmisión y recepción de datos/Report on results of data transmission and reception tests | 10d | 2015-10-26 | 2015-11-06 | 18 |  |  | 15d |  |  |  |  |  |
| 20 | 1.6 | **Capacitación AIXM/AIXM training** | 5d | 2015-09-28 | 2015-10-02 |  |  |  |  |  |  |  |  |  |
| 21 | 1.6.1 | Seminario AIXM/AIXM Seminar | 5d | 2015-09-28 | 2015-10-02 |  |  |  | 40d |  | finish no earlier than 2015-10-02 |  |  |  |
| 22 | 1.7 | **Documento guía en español/Guidance document in Spanish** | 15d | 2015-11-09 | 2015-11-27 |  |  |  |  |  |  |  |  |  |
| 23 | 1.7.1 | Elaboración del material guía acerca del concepto- AIXM para la Región CAR/SAM/Elaboration of guidance material regarding AIXM concept for CAR/SAM Region | 15d | 2015-11-09 | 2015-11-27 |  |  |  | 0d |  | start no earlier than 2015-11-09 |  |  |  |
